# CE non-merger

Schedule from MS Project, 2018-04-09 to 2019-10-02.
Reynolds, Smith and Hills, Inc.

## Calendars

- Standard: Mon-Fri 08:00-12:00, 13:00-17:00; Sat-Sun off.

## Schedule

| ID | WBS | Task | Type | Duration | Start | Finish | Predecessors | Total slack | Free slack | Constraint |
| --- | --- | --- | --- | --- | --- | --- | --- | --- | --- | --- |
| 1 | 1 | **Planning/Environmental Phase** |  | 336d | 2018-04-09 | 2019-07-22 |  | 52d |  |  |
| 2 | 1.1 | **Task Order 1** |  | 291d | 2018-04-09 | 2019-05-20 |  | 65d |  |  |
| 3 | 1.1.1 | **Obtain Task Order 1** |  | 291d | 2018-04-09 | 2019-05-20 |  | 65d |  |  |
| 4 | 1.1.1.1 | Review Scoping Report (if available) & CTP/MTP |  | 5d | 2018-04-09 | 2018-04-13 |  | 155d | 0d | start no earlier than 2018-04-09 |
| 5 | 1.1.1.2 | Contract Scoping Meeting |  | 5d | 2018-04-16 | 2018-04-20 | 4 | 155d | 0d | start no earlier than 2018-04-09 |
| 6 | 1.1.1.3 | Develop Scope & Fee Estimate |  | 5d | 2018-04-23 | 2018-04-27 | 5 | 155d | 0d |  |
| 7 | 1.1.1.4 | Negotiate |  | 5d | 2018-04-30 | 2018-05-04 | 6 | 155d | 0d |  |
| 8 | 1.1.1.5 | Finalize and Submit Scope & Fee Estimate |  | 5d | 2018-05-07 | 2018-05-11 | 7 | 155d | 0d |  |
| 9 | 1.1.1.6 | Obtain Notice to Proceed (NTP) | milestone | 0d | 2018-05-11 | 2018-05-11 | 8 | 155d | 0d | finish no earlier than 2017-04-10 |
| 10 | 1.1.1.7 | Complete Consultant Evaluation |  | 1d | 2018-11-19 | 2018-11-19 | 9 | 226d | 129d | start no earlier than 2018-11-19 |
| 11 | 1.1.1.8 | Complete Consultant Evaluation |  | 1d | 2019-05-20 | 2019-05-20 | 10 | 97d |  | start no earlier than 2019-05-20 |
| 12 | 1.1.2 | **Data Collection** |  | 32d | 2018-05-14 | 2018-06-26 |  | 120d |  |  |
| 13 | 1.1.2.1 | Develop Draft Study Area |  | 5d | 2018-05-14 | 2018-05-18 | 9 | 120d | 0d |  |
| 14 | 1.1.2.2 | Collect GIS Data |  | 5d | 2018-05-21 | 2018-05-25 | 13 | 120d | 0d |  |
| 15 | 1.1.2.3 | Review Long Range Transportation Plans (all modes) |  | 5d | 2018-05-28 | 2018-06-01 | 14 | 120d | 0d |  |
| 16 | 1.1.2.4 | Field Visit |  | 1d | 2018-06-04 | 2018-06-04 | 15, 14 | 120d | 0d |  |
| 17 | 1.1.2.5 | Finalize Study Area Map |  | 1d | 2018-06-05 | 2018-06-05 | 16 | 120d | 0d |  |
| 18 | 1.1.2.6 | Develop Environmental Feature Map |  | 5d | 2018-05-21 | 2018-05-25 | 13 | 127d | 0d |  |
| 19 | 1.1.2.7 | **ETRACS Request** |  | 11d | 2018-06-06 | 2018-06-20 |  | 120d |  |  |
| 20 | 1.1.2.7.1 | Historic Architecture Screening |  | 5d | 2018-06-06 | 2018-06-12 | 17 | 120d | 0d |  |
| 21 | 1.1.2.7.2 | Archaeology Screening |  | 5d | 2018-06-06 | 2018-06-12 | 17 | 120d | 0d |  |
| 22 | 1.1.2.7.3 | NRTR (if applicable) |  | 5d | 2018-06-06 | 2018-06-12 | 17 | 341d |  |  |
| 23 | 1.1.2.7.4 | Request Historic Architecture Survey (if needed) |  | 1d | 2018-06-13 | 2018-06-13 | 20 | 323d | 0d |  |
| 24 | 1.1.2.7.5 | Request Archaeology Survey (if needed) |  | 1d | 2018-06-13 | 2018-06-13 | 21 | 300d | 0d |  |
| 25 | 1.1.2.7.6 | Complete Histroic Architecture Survey (if needed) |  | 5d | 2018-06-14 | 2018-06-20 | 23 | 323d | 125d |  |
| 26 | 1.1.2.7.7 | Complete Archaeology Survey (if needed) |  | 5d | 2018-06-14 | 2018-06-20 | 24 | 300d | 125d |  |

Notes:
- 10: Consultant evaluations occur every 6 months after Notice to Proceed
- 18: Living document - update throughout process

| ID | WBS | Task | Duration | Start | Finish | Predecessors | Total slack | Free slack | Constraint |
| --- | --- | --- | --- | --- | --- | --- | --- | --- | --- |
| 27 | 1.1.2.8 | **GeoEnvironmental Screening** | 5d | 2018-05-21 | 2018-05-25 |  | 137d |  |  |
| 28 | 1.1.2.8.1 | Develop GeoEnvironmental Evaluation Memo | 5d | 2018-05-21 | 2018-05-25 | 13 | 137d | 17d |  |
| 29 | 1.1.2.9 | Section 4(f) Resource Identification | 5d | 2018-06-13 | 2018-06-19 | 18, 20, 21 | 120d | 0d |  |
| 30 | 1.1.2.10 | Section 6(f) Resource Identification | 5d | 2018-05-28 | 2018-06-01 | 18 | 132d | 12d |  |
| 31 | 1.1.2.11 | Perform Demographic Tool Screening | 5d | 2018-06-06 | 2018-06-12 | 17 | 125d | 5d |  |
| 32 | 1.1.2.12 | Complete Project Initiation Form (includes Purpose & Need) | 5d | 2018-06-20 | 2018-06-26 | 31, 29, 30, 18, 28, 14 | 120d | 0d |  |
| 33 | 1.1.2.13 | **Start of Study Letters (SOS)** | 15d | 2018-05-28 | 2018-06-15 |  | 127d |  |  |
| 34 | 1.1.2.13.1 | Develop Start of Study Letters | 5d | 2018-05-28 | 2018-06-01 | 18 | 127d | 0d |  |
| 35 | 1.1.2.13.2 | Review Start of Study Letters and Figures | 5d | 2018-06-04 | 2018-06-08 | 34 | 127d | 0d |  |
| 36 | 1.1.2.13.3 | Send out Start of Study Letters & Figures | 5d | 2018-06-11 | 2018-06-15 | 35 | 127d | 7d |  |
| 37 | 1.1.3 | Provide LGA Coordination Table to LGAs | 1d | 2018-05-14 | 2018-05-14 | 9 | 362d |  |  |
| 38 | 1.1.4 | Hold Project Initiation & Merger Screening Meeting | 1d | 2018-06-27 | 2018-06-27 | 32, 36 | 120d | 0d |  |
| 39 | 1.1.5 | Develop Project Management Plan | 5d | 2018-06-28 | 2018-07-04 | 38 | 120d | 0d |  |
| 40 | 1.1.6 | Obtain Initial Input from LGAs (can occur at External Scoping Meeting) | 1d | 2018-06-28 | 2018-06-28 | 38 | 294d | 174d |  |
| 41 | 1.2 | **Task Order 2** | 311d | 2018-05-14 | 2019-07-22 |  | 52d |  |  |
| 42 | 1.2.1 | **Obtain Task Order 2** | 273d | 2018-07-05 | 2019-07-22 |  | 52d |  |  |
| 43 | 1.2.1.1 | Develop Scope & Fee Estimate | 5d | 2018-07-05 | 2018-07-11 | 39 | 120d | 0d |  |
| 44 | 1.2.1.2 | Negotiate | 5d | 2018-07-12 | 2018-07-18 | 43 | 120d | 0d |  |
| 45 | 1.2.1.3 | Finalize and Submit Scope & Fee Estimate | 5d | 2018-07-19 | 2018-07-25 | 44 | 120d | 0d |  |
| 46 | 1.2.1.4 | Obtain Notice to Proceed (NTP) Task order 2 | 5d | 2018-07-26 | 2018-08-01 | 45 | 120d | 0d |  |
| 47 | 1.2.1.5 | Complete Consultant Evaluation | 1d | 2019-01-21 | 2019-01-21 | 46 | 181d | 129d | start no earlier than 2019-01-21 |
| 48 | 1.2.1.6 | Complete Consultant Evaluation | 1d | 2019-07-22 | 2019-07-22 | 47 | 52d |  | start no earlier than 2019-07-22 |
| 49 | 1.2.2 | **Traffic Analysis** | 70d | 2018-08-02 | 2018-11-07 |  | 120d |  |  |
| 50 | 1.2.2.1 | Traffic Counts | 5d | 2018-08-02 | 2018-08-08 | 46 | 120d | 0d |  |
| 51 | 1.2.2.2 | Review traffic counts | 5d | 2018-08-09 | 2018-08-15 | 50 | 120d | 0d |  |
| 52 | 1.2.2.3 | Prepare Interim Review | 5d | 2018-08-16 | 2018-08-22 | 51 | 120d | 0d |  |
| 53 | 1.2.2.4 | Prepare Draft Traffic Forecast | 5d | 2018-08-23 | 2018-08-29 | 52 | 120d | 0d |  |
| 54 | 1.2.2.5 | Submit Traffic Forecast | 5d | 2018-08-30 | 2018-09-05 | 53 | 120d | 0d |  |
| 55 | 1.2.2.6 | NCDOT Review Traffic Forecast | 5d | 2018-09-06 | 2018-09-12 | 54 | 120d | 0d |  |
| 56 | 1.2.2.7 | Revise Traffic Forecast | 5d | 2018-09-13 | 2018-09-19 | 55 | 120d | 0d |  |
| 57 | 1.2.2.8 | NCDOT Review Revised Traffic Forecast | 5d | 2018-09-20 | 2018-09-26 | 56 | 120d | 0d |  |
| 58 | 1.2.2.9 | Finalize Traffic Forecast | 5d | 2018-09-27 | 2018-10-03 | 57 | 120d | 0d |  |
| 59 | 1.2.2.10 | Prepare Draft Traffic Operations | 5d | 2018-10-04 | 2018-10-10 | 58 | 120d | 0d |  |
| 60 | 1.2.2.11 | NCDOT Review Traffic Operations | 5d | 2018-10-11 | 2018-10-17 | 59 | 120d | 0d |  |
| 61 | 1.2.2.12 | Revise Traffic Operations | 5d | 2018-10-18 | 2018-10-24 | 60 | 120d | 0d |  |
| 62 | 1.2.2.13 | NCDOT Review Revised Traffic Operations | 5d | 2018-10-25 | 2018-10-31 | 61 | 120d | 0d |  |
| 63 | 1.2.2.14 | Finalize Traffic Operations | 5d | 2018-11-01 | 2018-11-07 | 62 | 120d | 0d |  |

Notes:
- 36: Local Coordination & 30 day Clearinghouse Review
- 37: Local Coordination
- 40: Local Coordination
- 47: Consultant evaluations occur every 6 months after Notice to Proceed

| ID | WBS | Task | Duration | Start | Finish | Predecessors | Total slack | Free slack |
| --- | --- | --- | --- | --- | --- | --- | --- | --- |
| 64 | 1.2.3 | **Community Studies (CS) Reports** | 150d | 2018-08-02 | 2019-02-27 |  | 155d |  |
| 65 | 1.2.3.1 | **Community Characteristics Report (CCR) - if needed** | 50d | 2018-08-02 | 2018-10-10 |  | 255d |  |
| 66 | 1.2.3.1.1 | Prepare DCIA and DSA | 5d | 2018-08-02 | 2018-08-08 | 46 | 255d | 0d |
| 67 | 1.2.3.1.2 | NCDOT Review and approve DCIA and DSA | 5d | 2018-08-09 | 2018-08-15 | 66 | 255d | 0d |
| 68 | 1.2.3.1.3 | Demographic Data Pull using Demographic Tool | 5d | 2018-08-16 | 2018-08-22 | 67 | 255d | 0d |
| 69 | 1.2.3.1.4 | Prepare and Send out Input Forms | 5d | 2018-08-23 | 2018-08-29 | 68 | 255d | 0d |
| 70 | 1.2.3.1.5 | Send out Input Forms | 5d | 2018-08-30 | 2018-09-05 | 69 | 255d | 0d |
| 71 | 1.2.3.1.6 | Field Visit | 5d | 2018-09-06 | 2018-09-12 | 70 | 255d | 0d |
| 72 | 1.2.3.1.7 | Prepare Draft CCR | 5d | 2018-09-13 | 2018-09-19 | 71 | 255d | 0d |
| 73 | 1.2.3.1.8 | Submit Draft CCR for NCDOT Review | 5d | 2018-09-20 | 2018-09-26 | 72 | 255d | 0d |
| 74 | 1.2.3.1.9 | Respond to CS Comments and submit revised CCR | 5d | 2018-09-27 | 2018-10-03 | 73 | 255d | 0d |
| 75 | 1.2.3.1.10 | Finalize CCR | 5d | 2018-10-04 | 2018-10-10 | 74 | 255d |  |
| 76 | 1.2.3.2 | **Community Impact Assessment (CIA) - if needed** | 55d | 2018-12-13 | 2019-02-27 |  | 120d | 12d |
| 77 | 1.2.3.2.1 | Prepare/Revise DCIA and DSA | 5d | 2018-12-13 | 2018-12-19 | 157 | 120d | 0d |
| 78 | 1.2.3.2.2 | NCDOT Review and approve DCIA and DSA | 5d | 2018-12-20 | 2018-12-26 | 77 | 120d | 0d |
| 79 | 1.2.3.2.3 | Demographic Data Pull using Demographic Tool | 5d | 2018-12-27 | 2019-01-02 | 78 | 120d | 0d |
| 80 | 1.2.3.2.4 | Prepare and Send out Input Forms | 5d | 2019-01-03 | 2019-01-09 | 79 | 120d | 0d |
| 81 | 1.2.3.2.5 | Send out Input Forms | 5d | 2019-01-10 | 2019-01-16 | 80 | 120d | 0d |
| 82 | 1.2.3.2.6 | Field Visit | 5d | 2019-01-17 | 2019-01-23 | 81 | 120d | 0d |
| 83 | 1.2.3.2.7 | Prepare Draft CIA | 5d | 2019-01-24 | 2019-01-30 | 82 | 120d | 0d |
| 84 | 1.2.3.2.8 | Indirect and Cumulative Effects Screening (sICE) (if TICAs are present) | 5d | 2019-01-31 | 2019-02-06 | 83 | 120d | 0d |
| 85 | 1.2.3.2.9 | Submit Draft CIA for NCDOT Review | 5d | 2019-02-07 | 2019-02-13 | 84 | 120d | 0d |
| 86 | 1.2.3.2.10 | Respond to CS Comments and submit revised CIA | 5d | 2019-02-14 | 2019-02-20 | 85 | 120d | 0d |
| 87 | 1.2.3.2.11 | Finalize CIA | 5d | 2019-02-21 | 2019-02-27 | 86 | 120d | 0d |

Notes:
- 77: CCR predecessor is only needed IF a CCR was completed.

| ID | WBS | Task | Duration | Start | Finish | Predecessors | Total slack | Free slack |
| --- | --- | --- | --- | --- | --- | --- | --- | --- |
| 88 | 1.2.4 | **Land Use Screening Assessment (if needed)** | 5d | 2019-02-07 | 2019-02-13 |  | 165d |  |
| 89 | 1.2.4.1 | Determine if required based on sICE result | 5d | 2019-02-07 | 2019-02-13 | 84 | 165d |  |
| 90 | 1.2.5 | **Historic Architecture and Archaeology Effects (as needed)** | 10d | 2018-12-13 | 2018-12-26 |  | 175d |  |
| 91 | 1.2.5.1 | **Historic Architecture Effects** | 10d | 2018-12-13 | 2018-12-26 |  | 198d |  |
| 92 | 1.2.5.1.1 | Request through ETRACS | 5d | 2018-12-13 | 2018-12-19 | 39, 157, 25 | 198d | 0d |
| 93 | 1.2.5.1.2 | Pre-meeting held with NCDOT | 5d | 2018-12-20 | 2018-12-26 | 92 | 200d |  |
| 94 | 1.2.5.1.3 | Hold Section 106 & Section 4(f) Effects Meeting | 1d | 2018-12-20 | 2018-12-20 | 92 | 198d | 0d |
| 95 | 1.2.5.1.4 | Obtain Determination of Effects | 1d | 2018-12-21 | 2018-12-21 | 94 | 198d | 60d |
| 96 | 1.2.5.2 | **Archaeologic Effects** | 10d | 2018-12-13 | 2018-12-26 |  | 175d |  |
| 97 | 1.2.5.2.1 | Request through ETRACS (as needed) | 5d | 2018-12-13 | 2018-12-19 | 39, 157, 26 | 175d | 0d |
| 98 | 1.2.5.2.2 | Obtain Determination of Effects | 5d | 2018-12-20 | 2018-12-26 | 97 | 175d | 57d |
| 99 | 1.2.6 | **Natural Resources Technical Report** | 45d | 2018-05-28 | 2018-07-27 |  | 303d | 165d |
| 100 | 1.2.6.1 | Prepare Landowner Notification Letter | 5d | 2018-05-28 | 2018-06-01 | 171 | 303d | 0d |
| 101 | 1.2.6.2 | Field Visit for Wetland/Stream Delineation & T&E Habitat | 5d | 2018-06-04 | 2018-06-08 | 100 | 303d | 0d |
| 102 | 1.2.6.3 | Prepare Draft NRTR & PJD | 5d | 2018-06-11 | 2018-06-15 | 101 | 303d | 0d |
| 103 | 1.2.6.4 | Submit Draft NRTR & PJD for Review | 5d | 2018-06-18 | 2018-06-22 | 102 | 303d | 0d |
| 104 | 1.2.6.5 | Finalize NRTR & PJD Request | 5d | 2018-06-25 | 2018-06-29 | 103 | 303d | 0d |
| 105 | 1.2.6.6 | Submit PJD | 5d | 2018-07-02 | 2018-07-06 | 104 | 303d | 0d |
| 106 | 1.2.6.7 | JD Site visit | 5d | 2018-07-09 | 2018-07-13 | 105 | 303d | 0d |
| 107 | 1.2.6.8 | Survey verify wetland/stream delineation | 5d | 2018-07-16 | 2018-07-20 | 106 | 303d | 0d |
| 108 | 1.2.6.9 | Agency Review and Final PJD | 5d | 2018-07-23 | 2018-07-27 | 107 | 303d |  |
| 109 | 1.2.7 | **Biological Surveys** | 25d | 2018-06-06 | 2018-07-10 |  | 321d |  |
| 110 | 1.2.7.1 | Field Surveys | 5d | 2018-06-06 | 2018-06-12 | 17 | 321d | 0d |
| 111 | 1.2.7.2 | Prepare Draft Report | 5d | 2018-06-13 | 2018-06-19 | 110 | 321d | 0d |
| 112 | 1.2.7.3 | NCDOT Review | 5d | 2018-06-20 | 2018-06-26 | 111 | 321d | 0d |
| 113 | 1.2.7.4 | Finalize Report | 5d | 2018-06-27 | 2018-07-03 | 112 | 321d | 0d |
| 114 | 1.2.7.5 | If Formal Section 7 Consultation Required coordinate with BSG | 5d | 2018-07-04 | 2018-07-10 | 113 | 321d |  |

Notes:
- 93: Prepare prior to meeting with agencies

| ID | WBS | Task | Duration | Start | Finish | Predecessors | Total slack | Free slack | Constraint |
| --- | --- | --- | --- | --- | --- | --- | --- | --- | --- |
| 115 | 1.2.8 | **Section 4(f)/6(f) Resources** | 10d | 2019-02-28 | 2019-03-13 |  | 120d | 2d |  |
| 116 | 1.2.8.1 | **Section 4(f) Resource Coordination (non-historic resources)** | 10d | 2019-02-28 | 2019-03-13 |  | 120d |  |  |
| 117 | 1.2.8.1.1 | Coordinate with FHWA to confirm 4f use | 5d | 2019-02-28 | 2019-03-06 | 40, 87 | 120d | 0d |  |
| 118 | 1.2.8.1.2 | Coordinate with property owner to obtain de minimis | 5d | 2019-03-07 | 2019-03-13 | 117 | 120d |  |  |
| 119 | 1.2.8.2 | Section 6(f) Resource Coordination | 5d | 2019-02-28 | 2019-03-06 | 40, 87 | 125d |  |  |
| 120 | 1.2.9 | **Air Quality Report** | 30d | 2018-10-04 | 2018-11-14 |  | 205d | 87d |  |
| 121 | 1.2.9.1 | Determine Report type, Qualitative or Quantitative | 5d | 2018-10-04 | 2018-10-10 | 58 | 205d | 0d |  |
| 122 | 1.2.9.2 | **Qualitative Report** | 15d | 2018-10-11 | 2018-10-31 |  | 210d |  |  |
| 123 | 1.2.9.2.1 | Prepare Qualitative Report | 5d | 2018-10-11 | 2018-10-17 | 121 | 210d | 0d |  |
| 124 | 1.2.9.2.2 | NCDOT Review | 5d | 2018-10-18 | 2018-10-24 | 123 | 210d | 0d |  |
| 125 | 1.2.9.2.3 | Finalize Qualitative Air Quality Final Report | 5d | 2018-10-25 | 2018-10-31 | 124 | 210d | 5d |  |
| 126 | 1.2.9.3 | **Quantitative Report** | 20d | 2018-10-11 | 2018-11-07 |  | 205d |  |  |
| 127 | 1.2.9.3.1 | Prepare Model | 5d | 2018-10-11 | 2018-10-17 | 121 | 205d | 0d |  |
| 128 | 1.2.9.3.2 | Prepare Draft Quantitative Report | 5d | 2018-10-18 | 2018-10-24 | 127 | 205d | 0d |  |
| 129 | 1.2.9.3.3 | NCDOT Review | 5d | 2018-10-25 | 2018-10-31 | 128 | 205d | 0d | start no earlier than 2018-10-10 |
| 130 | 1.2.9.3.4 | Finalize Quantitative Air Quality Final Report | 5d | 2018-11-01 | 2018-11-07 | 129 | 205d | 0d | start no earlier than 2018-09-24 |
| 131 | 1.2.9.4 | Air Quality Report is completed | 5d | 2018-11-08 | 2018-11-14 | 125, 130 | 205d | 87d |  |
| 132 | 1.2.10 | **Concept Development (if necessary)** | 33d | 2018-08-02 | 2018-09-17 |  | 157d |  |  |
| 133 | 1.2.10.1 | Conduct Field Visit | 1d | 2018-08-02 | 2018-08-02 | 46 | 157d | 0d |  |
| 134 | 1.2.10.2 | Submit Design Criteria & Typ. Sections | 5d | 2018-08-03 | 2018-08-09 | 133 | 157d | 0d |  |
| 135 | 1.2.10.3 | NCDOT Review Design Criteria & Typ. Sections | 5d | 2018-08-10 | 2018-08-16 | 134 | 157d | 0d |  |
| 136 | 1.2.10.4 | Submit Concept Design Plans | 5d | 2018-08-17 | 2018-08-23 | 135 | 157d | 0d |  |
| 137 | 1.2.10.5 | NCDOT Review Concept Design Plans | 5d | 2018-08-24 | 2018-08-30 | 136 | 157d | 0d |  |
| 138 | 1.2.10.6 | Concept Review Meeting | 1d | 2018-08-31 | 2018-08-31 | 137 | 157d | 0d |  |
| 139 | 1.2.10.7 | Obtain Refined Cost Sharing Input from LGAs | 1d | 2018-09-03 | 2018-09-03 | 138 | 282d |  |  |
| 140 | 1.2.10.8 | Submit Revised Concept Design Plans | 5d | 2018-09-03 | 2018-09-07 | 138 | 157d | 0d |  |
| 141 | 1.2.10.9 | NCDOT Review Rev. Concept Design Plans | 5d | 2018-09-10 | 2018-09-14 | 140 | 157d | 0d |  |
| 142 | 1.2.10.10 | Concept Design Plans Approved | 1d | 2018-09-17 | 2018-09-17 | 141 | 157d | 37d |  |

Notes:
- 132: Conceptual design is based on lidar information and therefore is not precise. Conceptual design process is very basic and does not contain calculations or super elevations.
- 139: Local Coordination

| ID | WBS | Task | Type | Duration | Start | Finish | Predecessors | Total slack | Free slack | Constraint |
| --- | --- | --- | --- | --- | --- | --- | --- | --- | --- | --- |
| 143 | 1.2.11 | **Surveys** |  | 58d | 2018-05-14 | 2018-08-01 |  | 65d |  |  |
| 144 | 1.2.11.1 | Submit Survey Limits Request Map | milestone | 1d | 2018-05-14 | 2018-05-14 | 9 | 65d | 0d |  |
| 145 | 1.2.11.2 | Receive Shell Mapping Surveys from NCDOT |  | 5d | 2018-05-15 | 2018-05-21 | 144 | 357d |  |  |
| 146 | 1.2.11.3 | Receive Final Surveys from NCDOT |  | 1d | 2018-08-01 | 2018-08-01 | 144 | 9d | 0d | finish no earlier than 2018-08-01 |
| 147 | 1.2.12 | **Traffic Management Concept Design/ Constructability Review (If Applicable)** |  | 16d | 2018-12-13 | 2019-01-03 |  | 194d |  |  |
| 148 | 1.2.12.1 | Prepare Traffic Management Typical Sections |  | 5d | 2018-12-13 | 2018-12-19 | 157 | 194d | 0d |  |
| 149 | 1.2.12.2 | NCDOT Review Traffic Management Typ. Sects |  | 5d | 2018-12-20 | 2018-12-26 | 148 | 194d | 0d |  |
| 150 | 1.2.12.3 | Revise/Finalize Traffic Management Typ. Sects |  | 5d | 2018-12-27 | 2019-01-02 | 149 | 194d | 0d |  |
| 151 | 1.2.12.4 | Traffic Management plans Approved |  | 1d | 2019-01-03 | 2019-01-03 | 150 | 194d |  |  |
| 152 | 1.2.13 | **Functional Design Development (if necessary)** |  | 57d | 2018-11-08 | 2019-01-25 |  | 120d |  |  |
| 153 | 1.2.13.1 | Submit Functional Design Plans |  | 5d | 2018-11-08 | 2018-11-14 | 142, 63 | 120d | 0d |  |
| 154 | 1.2.13.2 | NCDOT Review Functional Design Plans |  | 5d | 2018-11-15 | 2018-11-21 | 153 | 120d | 0d |  |
| 155 | 1.2.13.3 | Submit Revised Functional Design Plans |  | 5d | 2018-11-22 | 2018-11-28 | 154 | 120d | 0d |  |
| 156 | 1.2.13.4 | NCDOT Review Rev. Functional Design Plans |  | 5d | 2018-11-29 | 2018-12-05 | 155 | 120d | 0d |  |
| 157 | 1.2.13.5 | Functional Design Plans Approved |  | 5d | 2018-12-06 | 2018-12-12 | 156 | 120d | 0d |  |
| 158 | 1.2.13.6 | Prepare public meeting maps |  | 5d | 2018-12-13 | 2018-12-19 | 157 | 158d | 0d |  |
| 159 | 1.2.13.7 | Submit Functional Design Quantities |  | 5d | 2018-12-13 | 2018-12-19 | 157 | 195d | 0d |  |
| 160 | 1.2.13.8 | NCDOT Review Functional Design Quantities |  | 5d | 2018-12-20 | 2018-12-26 | 159 | 195d | 57d |  |
| 161 | 1.2.13.9 | NCDOT Selection of Recommended Alternative |  | 1d | 2019-01-18 | 2019-01-18 | 189 | 158d | 0d |  |
| 162 | 1.2.13.10 | Provide Betterment Details / Costs to LGA |  | 1d | 2019-01-25 | 2019-01-25 | 190 | 178d |  |  |
| 163 | 1.2.14 | **Public Involvement** |  | 180d | 2018-05-21 | 2019-01-25 |  | 178d |  |  |
| 164 | 1.2.14.1 | **Website** |  | 130d | 2018-07-05 | 2019-01-02 |  | 195d |  |  |
| 165 | 1.2.14.1.1 | Prepare & Submit website request form via ETRACS |  | 5d | 2018-07-05 | 2018-07-11 | 39 | 320d |  |  |
| 166 | 1.2.14.1.2 | **Hold Local Officials Informational Meeting** |  | 5d | 2018-12-27 | 2019-01-02 |  | 195d |  |  |
| 167 | 1.2.14.1.2.1 | Prepare Local Officials Informations Meeting Invitation |  | 5d | 2018-12-27 | 2019-01-02 | 184 | 195d |  |  |
| 168 | 1.2.14.1.2.2 | Prepare Local Officials Informational Meeting Presentation (if necessary) |  | 5d | 2018-12-27 | 2019-01-02 | 184 | 195d |  |  |
| 169 | 1.2.14.1.2.3 | LGA Follow-up Meeting |  | 1d | 2018-12-27 | 2018-12-27 | 184 | 199d |  |  |

Notes:
- 146: Roadway cannot start without final surveys
- 147: The unit responsible for traffic management concept is traffic management unit, which is under transportation mobility and saftey.
- 152: Functional design is also based on lidar data. Functional design is not precise, does not contain detailed calculations, or super elevations. It contains basic drawings that are +/- 40 feet of the actual survey monuments.
- 162: Local Coordination
- 169: Local Coordination

| ID | WBS | Task | Type | Duration | Start | Finish | Predecessors | Total slack | Free slack |
| --- | --- | --- | --- | --- | --- | --- | --- | --- | --- |
| 170 | 1.2.14.2 | **Public Information Meeting** |  | 179d | 2018-05-21 | 2019-01-24 |  | 179d |  |
| 171 | 1.2.14.2.1 | Prepare Mailing List |  | 5d | 2018-05-21 | 2018-05-25 | 13 | 303d | 0d |
| 172 | 1.2.14.2.2 | Prepare Draft Postcard/Newsletter |  | 5d | 2018-12-13 | 2018-12-19 | 157 | 205d |  |
| 173 | 1.2.14.2.3 | NCDOT PI Review Postcard |  | 5d | 2018-12-13 | 2018-12-19 | 157 | 195d | 0d |
| 174 | 1.2.14.2.4 | Revise/Finalize Postcard/Newsletter |  | 5d | 2018-12-20 | 2018-12-26 | 173 | 195d | 0d |
| 175 | 1.2.14.2.5 | Send out Postcard/Newsletter (2 weeks prior to meeting) |  | 5d | 2018-12-27 | 2019-01-02 | 174 | 195d |  |
| 176 | 1.2.14.2.6 | Prepare Display Boards |  | 5d | 2018-12-13 | 2018-12-19 | 157 | 200d | 0d |
| 177 | 1.2.14.2.7 | NCDOT PI Review Display Boards |  | 5d | 2018-12-20 | 2018-12-26 | 176 | 200d |  |
| 178 | 1.2.14.2.8 | Prepare Visualizations |  | 5d | 2018-12-13 | 2018-12-19 | 157 | 195d | 0d |
| 179 | 1.2.14.2.9 | NCDOT review visualizations |  | 5d | 2018-12-20 | 2018-12-26 | 178 | 195d | 0d |
| 180 | 1.2.14.2.10 | Finalize Visualizations |  | 5d | 2018-12-27 | 2019-01-02 | 179 | 195d |  |
| 181 | 1.2.14.2.11 | Prepare Draft Handout, Comment Sheet, Title VI form |  | 5d | 2018-12-13 | 2018-12-19 | 157 | 195d | 0d |
| 182 | 1.2.14.2.12 | NCDOT review Handout, Comment Sheet, Title VI form |  | 5d | 2018-12-20 | 2018-12-26 | 181 | 195d | 0d |
| 183 | 1.2.14.2.13 | Finalize Handout, Comment Sheet, Title VI form |  | 5d | 2018-12-27 | 2019-01-02 | 182 | 195d |  |
| 184 | 1.2.14.2.14 | Post public meeting maps to project website |  | 5d | 2018-12-20 | 2018-12-26 | 157, 158 | 158d | 0d |
| 185 | 1.2.14.2.15 | Hold Public Meeting (Presentation of Concepts) | milestone | 1d | 2018-12-27 | 2018-12-27 | 184 | 158d | 0d |
| 186 | 1.2.14.2.16 | Receive Public Comments |  | 5d | 2018-12-28 | 2019-01-03 | 185 | 158d | 0d |
| 187 | 1.2.14.2.17 | Hold Post Hearing Meeting (if necessary) |  | 5d | 2019-01-04 | 2019-01-10 | 186 | 189d |  |
| 188 | 1.2.14.2.18 | Prepare meeting summary/comment summaries |  | 5d | 2019-01-04 | 2019-01-10 | 186 | 158d | 0d |
| 189 | 1.2.14.2.19 | NCDOT review PIM meeting and comment summary |  | 5d | 2019-01-11 | 2019-01-17 | 188 | 158d | 0d |
| 190 | 1.2.14.2.20 | Post Meeting & Comment Summaries to website |  | 5d | 2019-01-18 | 2019-01-24 | 189 | 178d | 0d |
| 191 | 1.2.14.3 | Prepare/Mail Newsletter Announcing Preferred Alternative |  | 5d | 2019-01-21 | 2019-01-25 | 161, 171, 184 | 178d |  |
| 192 | 1.2.15 | Type III Noise Memo (For projects that do not require a noise analysis) |  | 5d | 2018-12-13 | 2018-12-19 | 157 | 205d |  |
| 193 | 1.2.16 | **Traffic Noise Report** |  | 67d | 2018-12-13 | 2019-03-15 |  | 118d |  |
| 194 | 1.2.16.1 | **Work Plan (P-Finalize Study Area Map)** |  | 15d | 2018-12-13 | 2019-01-02 |  | 120d |  |
| 195 | 1.2.16.1.1 | Prepare draft Work Plan |  | 5d | 2018-12-13 | 2018-12-19 | 157 | 120d | 0d |
| 196 | 1.2.16.1.2 | NCDOT Review of Work Plan |  | 5d | 2018-12-20 | 2018-12-26 | 195 | 120d | 0d |
| 197 | 1.2.16.1.3 | Finalize Work plan and receive Right of Entry Letter |  | 5d | 2018-12-27 | 2019-01-02 | 196 | 120d | 0d |
| 198 | 1.2.16.2 | Perform field measurements (P-Finalize Work Plan and receive Right of Entry letter) |  | 5d | 2019-01-03 | 2019-01-09 | 197 | 120d | 2d |

| ID | WBS | Task | Type | Duration | Start | Finish | Predecessors | Total slack | Free slack | Constraint |
| --- | --- | --- | --- | --- | --- | --- | --- | --- | --- | --- |
| 199 | 1.2.16.3 | **Perform Validation (P-Perform Field measurements, Receive final surveys from NCDOT-need location surveys to develop TNM coordinates)** |  | 20d | 2019-01-14 | 2019-02-08 |  | 118d |  |  |
| 200 | 1.2.16.3.1 | Develop Model |  | 5d | 2019-01-14 | 2019-01-18 | 198 | 118d | 0d | start no earlier than 2019-01-14 |
| 201 | 1.2.16.3.2 | Draft Validation Memo (Some consultants submit email, not a formal memo) |  | 5d | 2019-01-21 | 2019-01-25 | 200 | 118d | 0d | start no earlier than 2019-01-21 |
| 202 | 1.2.16.3.3 | NCDOT review of Validation Memo |  | 5d | 2019-01-28 | 2019-02-01 | 201 | 118d | 0d |  |
| 203 | 1.2.16.3.4 | Finalize Validation Memo |  | 5d | 2019-02-04 | 2019-02-08 | 202 | 118d | 0d |  |
| 204 | 1.2.16.4 | **Prepare Draft TNR(P-Approved validation, traffic forecast, receive final surveys, functional design plans approved)** |  | 15d | 2019-02-11 | 2019-03-01 |  | 118d |  |  |
| 205 | 1.2.16.4.1 | Prepare existing and no-build TNM models |  | 5d | 2019-02-11 | 2019-02-15 | 203 | 118d | 0d |  |
| 206 | 1.2.16.4.2 | Prepare build condition TNM model and barrier analysis |  | 5d | 2019-02-18 | 2019-02-22 | 205 | 118d | 0d |  |
| 207 | 1.2.16.4.3 | Barrier optimization, as applicable |  | 5d | 2019-02-25 | 2019-03-01 | 206 | 118d | 0d |  |
| 208 | 1.2.16.5 | NCDOT review Draft TNR |  | 5d | 2019-03-04 | 2019-03-08 | 207 | 118d | 0d |  |
| 209 | 1.2.16.6 | Finalize TNR |  | 5d | 2019-03-11 | 2019-03-15 | 208 | 118d | 0d |  |
| 210 | 1.2.17 | **Environmental Document (CE)** |  | 25d | 2019-03-18 | 2019-04-19 |  | 118d |  |  |
| 211 | 1.2.17.1 | Prepare Draft Environmental Document - Follow CE Guidance |  | 5d | 2019-03-18 | 2019-03-22 | 201, 115, 120, 188, 76, 99, 161, 259, 223, 28, 63, 95, 98, 209, 160 | 138d |  |  |
| 212 | 1.2.17.2 | Prepare Draft Project Commitments Green Sheets |  | 5d | 2019-03-18 | 2019-03-22 | 161, 28, 63, 98, 115, 189, 87, 104, 209, 131 | 118d | 0d |  |
| 213 | 1.2.17.3 | NCDOT Review |  | 5d | 2019-03-25 | 2019-03-29 | 212 | 118d | 0d |  |
| 214 | 1.2.17.4 | Revise/Finalize Environmental Document & Green Sheets |  | 5d | 2019-04-01 | 2019-04-05 | 213 | 118d | 0d |  |
| 215 | 1.2.17.5 | FHWA Review (if necessary) |  | 5d | 2019-04-08 | 2019-04-12 | 214 | 118d | 0d |  |
| 216 | 1.2.17.6 | Revise/Finalize Environmental Document |  | 5d | 2019-04-15 | 2019-04-19 | 215 | 118d | 0d |  |
| 217 | 1.2.17.7 | Submit for Final Approval | milestone | 0d | 2019-04-19 | 2019-04-19 | 216 | 118d |  |  |
| 218 | 1.2.18 | **Hydraulic Planning Report** |  | 25d | 2018-12-13 | 2019-01-16 |  | 180d |  |  |
| 219 | 1.2.18.1 | Acquire existing structure reports (upstream/downstream) |  | 5d | 2018-12-13 | 2018-12-19 | 157 | 180d | 0d |  |
| 220 | 1.2.18.2 | Conduct Field Review |  | 5d | 2018-12-20 | 2018-12-26 | 219 | 180d | 0d |  |
| 221 | 1.2.18.3 | Submit Preliminary Hydraulic Planning Report |  | 5d | 2018-12-27 | 2019-01-02 | 220 | 180d | 0d |  |
| 222 | 1.2.18.4 | NCDOT Review Prelim Hydraulic Planning Report |  | 5d | 2019-01-03 | 2019-01-09 | 221 | 180d | 0d |  |
| 223 | 1.2.18.5 | Finalize Hydraulic Planning Report |  | 5d | 2019-01-10 | 2019-01-16 | 222 | 180d | 42d |  |

Notes:
- 211: Additional tasks may be necessary - follow CE Guidance.

| ID | WBS | Task | Duration | Start | Finish | Predecessors | Total slack | Free slack | Constraint |
| --- | --- | --- | --- | --- | --- | --- | --- | --- | --- |
| 224 | 2 | **Final Design Phase (Includes ROW Acquisition & Utility Relocation)** | 305d | 2018-08-02 | 2019-10-02 |  | 0d |  |  |
| 225 | 2.1 | **Task Order 3 (if needed)** | 305d | 2018-08-02 | 2019-10-02 |  | 0d |  |  |
| 226 | 2.1.1 | **Obtain Task Order 3** | 251d | 2018-08-02 | 2019-07-18 |  | 9d |  |  |
| 227 | 2.1.1.1 | Develop Scope & Fee Estimate | 5d | 2018-08-02 | 2018-08-08 | 146 | 9d | 0d |  |
| 228 | 2.1.1.2 | Negotiate | 5d | 2018-08-09 | 2018-08-15 | 227 | 9d | 0d |  |
| 229 | 2.1.1.3 | Finalize and Submit Scope & Fee Estimate | 5d | 2018-08-16 | 2018-08-22 | 228 | 9d | 0d |  |
| 230 | 2.1.1.4 | Obtain Notice to Proceed (NTP) | 5d | 2018-08-23 | 2018-08-29 | 229 | 9d | 0d |  |
| 231 | 2.1.1.5 | Complete Consultant Evaluation | 1d | 2019-01-18 | 2019-01-18 | 230 | 182d | 128d | start no earlier than 2019-01-18 |
| 232 | 2.1.1.6 | Complete Consultant Evaluation | 1d | 2019-07-18 | 2019-07-18 | 231 | 54d |  | start no earlier than 2019-07-18 |
| 233 | 2.1.2 | **Geotechnical Investigations/Design** | 72d | 2018-08-30 | 2018-12-07 |  | 213d |  |  |
| 234 | 2.1.2.1 | Roadway/Pavement/Structure Field Investigations and Designs | 5d | 2018-08-30 | 2018-09-05 | 230 | 264d | 51d |  |
| 235 | 2.1.2.2 | Prepare and Submit Roadway/Pavement/Structure recommendations to NCDOT | 5d | 2018-11-16 | 2018-11-22 | 234, 260 | 213d | 0d |  |
| 236 | 2.1.2.3 | NCDOT Review of Roadway/Pavement/Structures recommendations | 5d | 2018-11-23 | 2018-11-29 | 235 | 213d | 0d |  |
| 237 | 2.1.2.4 | Revise and resubmit Roadway/Pavement/Structures recommendations | 5d | 2018-11-30 | 2018-12-06 | 236 | 213d | 0d |  |
| 238 | 2.1.2.5 | NCDOT approves Roadway/Pavement/Structure recommendations | 1d | 2018-12-07 | 2018-12-07 | 237 | 213d |  |  |
| 239 | 2.1.3 | **GeoEnvironmental Investigations** | 16d | 2018-11-16 | 2018-12-07 |  | 40d |  |  |
| 240 | 2.1.3.1 | Prepare and submit phase 1 ESA to NCDOT | 5d | 2018-11-16 | 2018-11-22 | 260 | 40d | 0d |  |
| 241 | 2.1.3.2 | NCDOT review of phase 1 ESA | 5d | 2018-11-23 | 2018-11-29 | 240 | 40d | 0d |  |
| 242 | 2.1.3.3 | Revise and resubmit phase 1 ESA | 5d | 2018-11-30 | 2018-12-06 | 241 | 40d | 0d |  |
| 243 | 2.1.3.4 | NCDOT approves phase 1 ESA | 1d | 2018-12-07 | 2018-12-07 | 242 | 40d | 31d |  |
| 244 | 2.1.4 | **Roadway Design** | 230d | 2018-08-30 | 2019-07-17 |  | 9d |  |  |
| 245 | 2.1.4.1 | **15% Roadway Design /Final Surveys** | 30d | 2018-08-30 | 2018-10-10 |  | 9d |  |  |
| 246 | 2.1.4.1.1 | LGA Screening at LPMO or Division | 1d | 2018-08-30 | 2018-08-30 | 230, 146 | 284d |  |  |
| 247 | 2.1.4.1.2 | Submit Design Criteria & Typ. Sections | 5d | 2018-08-30 | 2018-09-05 | 230, 146 | 9d | 0d |  |
| 248 | 2.1.4.1.3 | NCDOT Review Design Criteria & Typ. Sections | 5d | 2018-09-06 | 2018-09-12 | 247 | 9d | 0d |  |
| 249 | 2.1.4.1.4 | Submit Revised Design Criteria & Typ. Sect. | 5d | 2018-09-13 | 2018-09-19 | 248 | 9d | 0d |  |
| 250 | 2.1.4.1.5 | NCDOT Rev. Des. Criteria & Typ. Sect. | 5d | 2018-09-20 | 2018-09-26 | 249 | 9d | 0d |  |
| 251 | 2.1.4.1.6 | Submit Line & Grade Plans (15%) | 5d | 2018-09-27 | 2018-10-03 | 250, 146 | 9d | 0d |  |
| 252 | 2.1.4.1.7 | NCDOT Review 15% Plans | 5d | 2018-10-04 | 2018-10-10 | 251 | 9d | 0d |  |

Notes:
- 231: Consultant evaluations occur every 6 months after Notice to Proceed
- 246: Local Coordination

| ID | WBS | Task | Type | Duration | Start | Finish | Predecessors | Total slack | Free slack | Constraint |
| --- | --- | --- | --- | --- | --- | --- | --- | --- | --- | --- |
| 253 | 2.1.4.2 | **25% Roadway Design** |  | 26d | 2018-10-11 | 2018-11-15 |  | 9d |  |  |
| 254 | 2.1.4.2.1 | Obtain LGA Commitment on Requested Items/Betterments |  | 1d | 2018-10-11 | 2018-10-11 | 252 | 254d |  |  |
| 255 | 2.1.4.2.2 | Submit 25% Preliminary Roadway Plans |  | 5d | 2018-10-11 | 2018-10-17 | 252 | 9d | 0d |  |
| 256 | 2.1.4.2.3 | NCDOT Review (25% Preliminary Roadway Plans) |  | 5d | 2018-10-18 | 2018-10-24 | 255 | 9d | 0d |  |
| 257 | 2.1.4.2.4 | Submit Revised Prelim Roadway Plans (25%) |  | 5d | 2018-10-25 | 2018-10-31 | 256 | 9d | 0d |  |
| 258 | 2.1.4.2.5 | NCDOT Review (Rev. 25% Prelim. Roadway Plans) |  | 5d | 2018-11-01 | 2018-11-07 | 257 | 9d | 0d |  |
| 259 | 2.1.4.2.6 | NCDOT Approves 25% Prelim. Plans |  | 1d | 2018-11-08 | 2018-11-08 | 258 | 9d | 0d |  |
| 260 | 2.1.4.2.7 | Distribute Approved 25% Plans |  | 5d | 2018-11-09 | 2018-11-15 | 259 | 40d | 0d |  |
| 261 | 2.1.4.3 | **65% Roadway Design/ Final Design Field Inspection (FDFI)** |  | 74d | 2018-11-16 | 2019-02-27 |  | 56d |  |  |
| 262 | 2.1.4.3.1 | Submit Form Letter Requesting Geotech Reports & Pavement Design |  | 5d | 2018-11-16 | 2018-11-22 | 260 | 224d |  |  |
| 263 | 2.1.4.3.2 | Prepare and Submit 65% Plans |  | 5d | 2019-01-22 | 2019-01-28 | 243, 327, 308, 395, 396 | 9d | 0d |  |
| 264 | 2.1.4.3.3 | NCDOT Review (65% Plans) |  | 5d | 2019-01-29 | 2019-02-04 | 263 | 9d | 0d |  |
| 265 | 2.1.4.3.4 | Revise and Resubmit FDFI Plans |  | 5d | 2019-02-05 | 2019-02-11 | 264 | 9d | 0d |  |
| 266 | 2.1.4.3.5 | NCDOT Approves FDFI Plans |  | 1d | 2019-02-12 | 2019-02-12 | 265 | 9d | 0d |  |
| 267 | 2.1.4.3.6 | Submit FDFI Plans for Distribution |  | 5d | 2019-02-13 | 2019-02-19 | 266 | 9d | 0d |  |
| 268 | 2.1.4.3.7 | FDFI Plan Review |  | 5d | 2019-02-20 | 2019-02-26 | 267 | 9d | 0d |  |
| 269 | 2.1.4.3.8 | LGA Refresh Meeting |  | 1d | 2019-02-27 | 2019-02-27 | 268 | 155d |  |  |
| 270 | 2.1.4.3.9 | Combined Field Inspection Held |  | 1d | 2019-02-27 | 2019-02-27 | 268 | 9d | 0d |  |
| 271 | 2.1.4.4 | **75% Roadway Design/ Right of Way (ROW) Plans** |  | 21d | 2019-02-27 | 2019-03-27 |  | 9d |  |  |
| 272 | 2.1.4.4.1 | Incorporate FDFI Meeting Review Comments |  | 5d | 2019-02-28 | 2019-03-06 | 397, 270 | 9d | 0d |  |
| 273 | 2.1.4.4.2 | Submit ROW Plans |  | 5d | 2019-03-07 | 2019-03-13 | 272, 397 | 9d | 0d |  |
| 274 | 2.1.4.4.3 | NCDOT Review of ROW Plans |  | 5d | 2019-03-14 | 2019-03-20 | 273 | 9d | 0d |  |
| 275 | 2.1.4.4.4 | Revise and Resubmit ROW Plans |  | 5d | 2019-03-21 | 2019-03-27 | 274 | 9d | 0d |  |
| 276 | 2.1.4.4.5 | NCDOT Approves & Distributes ROW Plans | milestone | 0d | 2019-03-27 | 2019-03-27 | 275 | 9d | 0d |  |
| 277 | 2.1.4.4.6 | ROW Plans Approved/Request Funding/Begin ROW Acquisition |  | 5d | 2019-02-27 | 2019-03-05 | 304, 389, 398 | 25d | 0d |  |
| 278 | 2.1.4.5 | Prepare LGA/Municipal Agreement |  | 1d | 2019-07-17 | 2019-07-17 | 277 | 55d |  | start no earlier than 2019-07-17 |
| 279 | 2.1.4.6 | Submit Form Letter Requesting Temp. Shoring Design from Geotech |  | 5d | 2019-03-06 | 2019-03-12 | 277 | 146d |  |  |

Notes:
- 254: Local Coordination
- 259: Distribute plans to geotech & hydro; request property ties (5 Form letter - geotech, hydro, survey, pavement design, structures)
- 260: If this is large bridge project use BSR approval as predecessor
- 269: Local Coordination
- 278: Local Coordination

| ID | WBS | Task | Duration | Start | Finish | Predecessors | Total slack | Free slack |
| --- | --- | --- | --- | --- | --- | --- | --- | --- |
| 280 | 2.1.4.7 | **Permit Drawings Package** | 21d | 2019-04-12 | 2019-05-10 |  | 93d |  |
| 281 | 2.1.4.7.1 | Prepare & Submit Permit Drawings Pkg to NCDOT | 5d | 2019-04-12 | 2019-04-18 | 328, 287 | 93d | 0d |
| 282 | 2.1.4.7.2 | NCDOT Review Permit Drawing Package | 5d | 2019-04-19 | 2019-04-25 | 281 | 93d | 0d |
| 283 | 2.1.4.7.3 | Revise & Resubmit Permit Drawing Package | 5d | 2019-04-26 | 2019-05-02 | 282 | 93d | 0d |
| 284 | 2.1.4.7.4 | NCDOT Approves Permit Drawing Package | 1d | 2019-05-03 | 2019-05-03 | 283 | 93d | 0d |
| 285 | 2.1.4.7.5 | Send Approved Permit Drawing Package to USACE & NCDWR | 5d | 2019-05-06 | 2019-05-10 | 284 | 93d | 0d |
| 286 | 2.1.4.8 | **90% Roadway Design** | 21d | 2019-04-05 | 2019-05-03 |  | 11d |  |
| 287 | 2.1.4.8.1 | Prepare and Submit 90% Plans | 5d | 2019-04-05 | 2019-04-11 | 306, 329, 146 | 11d | 0d |
| 288 | 2.1.4.8.2 | NCDOT Review (90% Roadway Plans) | 5d | 2019-04-12 | 2019-04-18 | 287 | 11d | 0d |
| 289 | 2.1.4.8.3 | Revise and Resubmit 90% Plans | 5d | 2019-04-19 | 2019-04-25 | 288 | 11d | 0d |
| 290 | 2.1.4.8.4 | NCDOT Review of Revised 90% Plans | 5d | 2019-04-26 | 2019-05-02 | 289 | 11d | 0d |
| 291 | 2.1.4.8.5 | NCDOT Approves 90% Plans | 1d | 2019-05-03 | 2019-05-03 | 290 | 11d | 0d |
| 292 | 2.1.4.9 | Design Noise Report (DNR) | 5d | 2019-05-06 | 2019-05-10 | 291 | 103d |  |
| 293 | 2.1.4.10 | Submit Pre-Let Field Inspection Plans for Distribution | 5d | 2019-04-19 | 2019-04-25 | 288 | 113d | 0d |
| 294 | 2.1.4.11 | Pre-Let Field Inspection | 1d | 2019-04-26 | 2019-04-26 | 293 | 113d |  |
| 295 | 2.1.4.12 | **100% Roadway Plans/ Final Design** | 33d | 2019-05-06 | 2019-06-19 |  | 9d |  |
| 296 | 2.1.4.12.1 | Prepare & Submit Final Roadway Plans to NCDOT | 5d | 2019-05-06 | 2019-05-10 | 291 | 11d | 0d |
| 297 | 2.1.4.12.2 | NCDOT Review (100% Roadway Plans) | 5d | 2019-05-13 | 2019-05-17 | 296 | 15d | 0d |
| 298 | 2.1.4.12.3 | Revise and Resubmit Final Roadway Plans | 5d | 2019-05-20 | 2019-05-24 | 297 | 15d | 0d |
| 299 | 2.1.4.12.4 | NCDOT Review of Revised Final Roadway Plans | 5d | 2019-05-27 | 2019-05-31 | 298 | 15d | 6d |
| 300 | 2.1.4.12.5 | Submit Final Plans and Special Provisions to Contracts Unit - (Plan Checking) | 1d | 2019-06-11 | 2019-06-11 | 299, 409, 387 | 9d | 0d |
| 301 | 2.1.4.12.6 | NCDOT (Plan Checking) Review of Final Plans | 5d | 2019-06-12 | 2019-06-18 | 300 | 9d | 0d |
| 302 | 2.1.4.12.7 | NCDOT Approves Final Roadway Plans | 1d | 2019-06-19 | 2019-06-19 | 301 | 9d | 0d |
| 303 | 2.1.5 | **Right Of Way/Acquisition** | 32d | 2019-02-20 | 2019-04-04 |  | 9d |  |
| 304 | 2.1.5.1 | Prepare ROW Estimate | 5d | 2019-02-20 | 2019-02-26 | 267 | 25d | 0d |
| 305 | 2.1.5.2 | ROW Acquisition | 5d | 2019-03-28 | 2019-04-03 | 276, 277 | 9d | 0d |
| 306 | 2.1.5.3 | ROW Certification- NCDOT | 1d | 2019-04-04 | 2019-04-04 | 305 | 9d | 0d |

Notes:
- 286: All other disciplines complete their 90% plans alongside roadways 90% plans

| ID | WBS | Task | Duration | Start | Finish | Predecessors | Total slack | Free slack |
| --- | --- | --- | --- | --- | --- | --- | --- | --- |
| 307 | 2.1.6 | **Erosion Control Design** | 105d | 2018-12-10 | 2019-05-03 |  | 9d |  |
| 308 | 2.1.6.1 | Review Potential R/W Impacts for EC Measures | 5d | 2018-12-10 | 2018-12-14 | 323FF | 35d | 26d |
| 309 | 2.1.6.2 | Submit Prelim EC Plans | 5d | 2018-12-24 | 2018-12-28 | 324, 332 | 73d | 0d |
| 310 | 2.1.6.3 | NCDOT Review Prelim EC Plans | 5d | 2018-12-31 | 2019-01-04 | 309 | 73d | 64d |
| 311 | 2.1.6.4 | Prepare & Submit Final EC Plans | 5d | 2019-04-05 | 2019-04-11 | 310, 327, 308, 306 | 9d | 0d |
| 312 | 2.1.6.5 | NCDOT Review Final EC Plans | 5d | 2019-04-12 | 2019-04-18 | 311 | 9d | 0d |
| 313 | 2.1.6.6 | Submit Revised Final EC Plans | 5d | 2019-04-19 | 2019-04-25 | 312 | 9d | 0d |
| 314 | 2.1.6.7 | NCDOT Review Revised Final EC Plans | 5d | 2019-04-26 | 2019-05-02 | 313 | 9d | 0d |
| 315 | 2.1.6.8 | Final EC Plans Approved | 1d | 2019-05-03 | 2019-05-03 | 314 | 9d | 0d |
| 316 | 2.1.7 | **Hydraulic Design/ Drainage Plans** | 94d | 2018-11-09 | 2019-03-20 |  | 9d |  |
| 317 | 2.1.7.1 | Field Reconnaissance & Supplementary Surveys | 5d | 2018-11-09 | 2018-11-15 | 259 | 9d | 0d |
| 318 | 2.1.7.2 | **BSR/CSR** | 16d | 2018-11-16 | 2018-12-07 |  | 9d |  |
| 319 | 2.1.7.2.1 | Submit Draft BSR/CSR | 5d | 2018-11-16 | 2018-11-22 | 317 | 9d | 0d |
| 320 | 2.1.7.2.2 | NCDOT Review BSR/CSR (Hydro & Structures) | 5d | 2018-11-23 | 2018-11-29 | 319 | 9d | 0d |
| 321 | 2.1.7.2.3 | Submit Rev. BSR/CSR | 5d | 2018-11-30 | 2018-12-06 | 320 | 9d | 0d |
| 322 | 2.1.7.2.4 | BSR/CSR Approved | 1d | 2018-12-07 | 2018-12-07 | 321 | 9d | 0d |
| 323 | 2.1.7.3 | Prepare and submit Roadway Drainage Plan Package to NCDOT | 5d | 2018-12-10 | 2018-12-14 | 322 | 9d | 0d |
| 324 | 2.1.7.4 | NCDOT Review Drainage Plan Package | 5d | 2018-12-17 | 2018-12-21 | 323 | 9d | 0d |
| 325 | 2.1.7.5 | Revise & Resubmit Roadway Drainage Plan Pkg | 5d | 2018-12-24 | 2018-12-28 | 324 | 19d | 0d |
| 326 | 2.1.7.6 | NCDOT Review Revised Drainage Plan Pkg | 5d | 2018-12-31 | 2019-01-04 | 325 | 19d | 0d |
| 327 | 2.1.7.7 | NCDOT Approves Drainage Design | 1d | 2019-01-07 | 2019-01-07 | 326 | 19d | 10d |
| 328 | 2.1.7.8 | Review & Rework | 5d | 2019-03-07 | 2019-03-13 | 270, 273FF | 22d | 0d |
| 329 | 2.1.7.9 | Drainage Summary Sheets | 5d | 2019-03-14 | 2019-03-20 | 328 | 22d | 11d |
| 330 | 2.1.8 | **Structural Design** | 31d | 2018-11-09 | 2018-12-21 |  | 94d |  |
| 331 | 2.1.8.1 | Submit Prelim General Drawings (PGD's) | 5d | 2018-11-09 | 2018-11-15 | 259 | 94d | 0d |
| 332 | 2.1.8.2 | NCDOT Review (PGD's) | 5d | 2018-11-16 | 2018-11-22 | 331 | 94d | 0d |
| 333 | 2.1.8.3 | Incorporate PGD review comments and submit 90% structure plans to SMU | 5d | 2018-11-23 | 2018-11-29 | 332 | 104d | 0d |
| 334 | 2.1.8.4 | SMU review of 90% structure plans | 5d | 2018-11-30 | 2018-12-06 | 333 | 104d | 0d |
| 335 | 2.1.8.5 | Incorporate SMU review comments on 90% structure plans into 100% structure plans | 5d | 2018-12-07 | 2018-12-13 | 334 | 104d | 0d |
| 336 | 2.1.8.6 | NCDOT Review (Rev. Final Structure Plans) | 5d | 2018-12-14 | 2018-12-20 | 335 | 104d | 0d |
| 337 | 2.1.8.7 | Final Structure Plans Approved | 1d | 2018-12-21 | 2018-12-21 | 336 | 104d | 95d |

Notes:
- 325: 100% submittal is all that is needed if no BSR

| ID | WBS | Task | Duration | Start | Finish | Predecessors | Total slack | Free slack | Constraint |
| --- | --- | --- | --- | --- | --- | --- | --- | --- | --- |
| 338 | 2.1.9 | **Traffic Control Design** | 83d | 2019-02-21 | 2019-06-17 |  | 53d |  |  |
| 339 | 2.1.9.1 | **Traffic Control Staging Concept (25%)** | 36d | 2019-02-21 | 2019-04-11 |  | 124d |  |  |
| 340 | 2.1.9.1.1 | NCDOT Review Traffic Control Staging Concept | 5d | 2019-02-28 | 2019-03-06 | 266, 342 | 144d | 0d |  |
| 341 | 2.1.9.1.2 | 25% Review Meeting with NCDOT | 1d | 2019-03-07 | 2019-03-07 | 270FF, 340 | 144d | 20d |  |
| 342 | 2.1.9.1.3 | Prepare and submit Traffic Control Staging Concept | 5d | 2019-02-21 | 2019-02-27 | 270FF | 144d | 0d |  |
| 343 | 2.1.9.1.4 | Revise / Incorporate Review Comments from FDFI Meeting | 5d | 2019-04-05 | 2019-04-11 | 341, 287FF | 124d |  |  |
| 344 | 2.1.9.2 | **90% Traffic Control Plans** | 10d | 2019-04-05 | 2019-04-18 |  | 22d |  |  |
| 345 | 2.1.9.2.1 | Prepare and Submit 90% Traffic Control Plans | 5d | 2019-04-05 | 2019-04-11 | 287FF | 22d | 0d |  |
| 346 | 2.1.9.2.2 | NCDOT Review 90% Traffic Control Plans | 5d | 2019-04-12 | 2019-04-18 | 345 | 22d | 11d |  |
| 347 | 2.1.9.3 | **100% Traffic Control Plans** | 31d | 2019-05-06 | 2019-06-17 |  | 11d |  |  |
| 348 | 2.1.9.3.1 | Incorporate 90% Plan Review Comments and Submit 100% Traffic Control Plans to NCDOT | 5d | 2019-05-06 | 2019-05-10 | 346, 296SS | 11d | 0d |  |
| 349 | 2.1.9.3.2 | NCDOT Review of 100% Traffic Control Plans | 5d | 2019-05-13 | 2019-05-17 | 348 | 11d | 0d |  |
| 350 | 2.1.9.3.3 | Revise & Resubmit 100% Traffic Control Plans | 5d | 2019-05-20 | 2019-05-24 | 349 | 11d | 0d |  |
| 351 | 2.1.9.3.4 | NCDOT Review of Revised 100% Traffic Control Plans | 5d | 2019-05-27 | 2019-05-31 | 350 | 11d | 0d |  |
| 352 | 2.1.9.3.5 | Submit TMP & Traffic Control Plans (Plan Checking) | 5d | 2019-06-03 | 2019-06-07 | 351 | 11d | 0d |  |
| 353 | 2.1.9.3.6 | NCDOT (Plan Checking) Review of Final Plans | 5d | 2019-06-10 | 2019-06-14 | 352 | 11d | 0d |  |
| 354 | 2.1.9.3.7 | NCDOT approves 100% Traffic Control Plans | 1d | 2019-06-17 | 2019-06-17 | 353 | 11d | 2d |  |
| 355 | 2.1.10 | **Pavement Marking** | 127d | 2019-04-05 | 2019-09-30 |  | 2d |  |  |
| 356 | 2.1.10.1 | **90% Pavement Marking Plans** | 10d | 2019-04-05 | 2019-04-18 |  | 88d |  |  |
| 357 | 2.1.10.1.1 | Prepare and Submit 90% Pavement Marking Plans | 5d | 2019-04-05 | 2019-04-11 | 287SS | 88d | 0d |  |
| 358 | 2.1.10.1.2 | NCDOT Review of 90% Pavement Marking Plans | 5d | 2019-04-12 | 2019-04-18 | 357 | 88d | 11d |  |
| 359 | 2.1.10.2 | **100% Pavement Marking Plans** | 106d | 2019-05-06 | 2019-09-30 |  | 2d |  |  |
| 360 | 2.1.10.2.1 | Incorporate 90% Plan Review Comments and Submit 100% Pavement Marking Plans to NCDOT. | 5d | 2019-05-06 | 2019-05-10 | 296SS, 358 | 77d | 75d |  |
| 361 | 2.1.10.2.2 | NCDOT Review of 100% Pavement Marking Plans | 5d | 2019-08-26 | 2019-08-30 | 360 | 2d | 0d | start no earlier than 2019-08-26 |
| 362 | 2.1.10.2.3 | Revise & resubmit 100% Pvmt. Marking Plans | 5d | 2019-09-02 | 2019-09-06 | 361 | 2d | 0d | start no earlier than 2019-08-15 |
| 363 | 2.1.10.2.4 | NCDOT Review Revised 100% Pvmt. Marking Plans | 5d | 2019-09-09 | 2019-09-13 | 362 | 2d | 0d | start no earlier than 2019-08-26 |
| 364 | 2.1.10.2.5 | Sumit 100% Pvmt. Marking Plans to NCDOT (Plan Checking) | 5d | 2019-09-16 | 2019-09-20 | 363 | 2d | 0d | start no earlier than 2019-08-15 |
| 365 | 2.1.10.2.6 | NCDOT (Plan Checking) Review of 100% Pvmt. Marking Plans | 5d | 2019-09-23 | 2019-09-27 | 364 | 2d | 0d | start no earlier than 2019-08-26 |
| 366 | 2.1.10.2.7 | NCDOT Approves 100% Pavement Marking Plans | 1d | 2019-09-30 | 2019-09-30 | 365 | 2d |  | start no earlier than 2019-08-15 |

| ID | WBS | Task | Duration | Start | Finish | Predecessors | Total slack | Free slack |
| --- | --- | --- | --- | --- | --- | --- | --- | --- |
| 367 | 2.1.11 | **Signing Plans & Special Provisions** | 52d | 2019-04-05 | 2019-06-17 |  | 77d |  |
| 368 | 2.1.11.1 | **90% Signing Plans** | 10d | 2019-04-05 | 2019-04-18 |  | 88d |  |
| 369 | 2.1.11.1.1 | Prepare and Submit 90% Interim Signing Plans | 5d | 2019-04-05 | 2019-04-11 | 287SS | 88d | 0d |
| 370 | 2.1.11.1.2 | NCDOT Review of 90% Interim Signing Plans | 5d | 2019-04-12 | 2019-04-18 | 369 | 88d | 11d |
| 371 | 2.1.11.2 | **100% Final Signing Plans & Project Special Provisions** | 31d | 2019-05-06 | 2019-06-17 |  | 77d |  |
| 372 | 2.1.11.2.1 | Incorporate 90% Plan Review Comments and Submit 100% Final Signing Plans & SPS to NCDOT | 5d | 2019-05-06 | 2019-05-10 | 370, 296SS | 77d | 0d |
| 373 | 2.1.11.2.2 | NCDOT Review of 100% Final Signing Plans & SPs | 5d | 2019-05-13 | 2019-05-17 | 372 | 77d | 0d |
| 374 | 2.1.11.2.3 | Revise and Resubmit 100% Final Signing Plans & SPs | 5d | 2019-05-20 | 2019-05-24 | 373 | 77d | 0d |
| 375 | 2.1.11.2.4 | NCDOT Review of Revised 100% Final Signing Plans & SPs | 5d | 2019-05-27 | 2019-05-31 | 374 | 77d | 0d |
| 376 | 2.1.11.2.5 | Submit 100% Final Signing Plans & SPs to NCDOT (Plan Checking) | 5d | 2019-06-03 | 2019-06-07 | 375 | 77d | 0d |
| 377 | 2.1.11.2.6 | NCDOT (Plan Checking) Review of 100% Final Signing Plans & SPs | 5d | 2019-06-10 | 2019-06-14 | 376 | 77d | 0d |
| 378 | 2.1.11.2.7 | NCDOT approves 100% Signing Final sealed plans & SPs | 1d | 2019-06-17 | 2019-06-17 | 377 | 77d |  |
| 379 | 2.1.12 | **Environmental Permit** | 26d | 2019-05-06 | 2019-06-10 |  | 9d |  |
| 380 | 2.1.12.1 | Prepare and submit Pre-Construction Notification (PCN) to NCDOT | 5d | 2019-05-13 | 2019-05-17 | 389, 285 | 93d | 0d |
| 381 | 2.1.12.2 | NCDOT review of PCN application | 5d | 2019-05-20 | 2019-05-24 | 380 | 93d |  |
| 382 | 2.1.12.3 | Revise and resubmit PCN application to NCDOT for approval | 5d | 2019-05-06 | 2019-05-10 | 327, 315, 337 | 9d | 0d |
| 383 | 2.1.12.4 | NCDOT approves PCN application | 5d | 2019-05-13 | 2019-05-17 | 382 | 9d | 0d |
| 384 | 2.1.12.5 | Submit Pre-Construction Notification (PCN) to NDWR & USACE | 5d | 2019-05-20 | 2019-05-24 | 383 | 9d | 0d |
| 385 | 2.1.12.6 | NCDWR & USACE review of PCN | 5d | 2019-05-27 | 2019-05-31 | 384 | 9d | 0d |
| 386 | 2.1.12.7 | Address NCDWR & USACE review comments and PCN | 5d | 2019-06-03 | 2019-06-07 | 385 | 9d | 0d |
| 387 | 2.1.12.8 | NCDRW & USACE approve PCN | 1d | 2019-06-10 | 2019-06-10 | 386 | 9d | 0d |
| 388 | 2.1.13 | **State Minimum Criteria and Design Checklist (MCDC)** | 1d | 2018-11-09 | 2018-11-09 |  | 102d |  |
| 389 | 2.1.13.1 | NCDOT approves MCDC | 1d | 2018-11-09 | 2018-11-09 | 259 | 102d | 77d |
| 390 | 2.1.14 | **Utility Coordination and Conflict Resolution** | 98d | 2018-12-24 | 2019-05-08 |  | 9d |  |
| 391 | 2.1.14.1 | **Utility Task Order 1** | 31d | 2018-12-24 | 2019-02-04 |  | 9d |  |
| 392 | 2.1.14.1.1 | Review approved 25% plans | 5d | 2018-12-24 | 2018-12-28 | 324 | 9d | 0d |
| 393 | 2.1.14.1.2 | Utility coordination kick-off meeting | 1d | 2018-12-31 | 2018-12-31 | 392 | 9d | 0d |
| 394 | 2.1.14.1.3 | Issue preliminary utility analysis and progress report UAPR | 5d | 2019-01-01 | 2019-01-07 | 393 | 9d | 0d |
| 395 | 2.1.14.1.4 | Preliminary utility owner relocation plans | 5d | 2019-01-08 | 2019-01-14 | 394 | 9d | 0d |
| 396 | 2.1.14.1.5 | Preliminary PUEs to Roadway | 5d | 2019-01-15 | 2019-01-21 | 395, 394 | 9d | 0d |
| 397 | 2.1.14.1.6 | Final PUEs to Roadway | 5d | 2019-01-22 | 2019-01-28 | 396 | 31d | 0d |
| 398 | 2.1.14.1.7 | Provide utilities by others (UbO) Construction Cost Estimate | 5d | 2019-01-29 | 2019-02-04 | 397 | 41d | 16d |

| ID | WBS | Task | Duration | Start | Finish | Predecessors | Total slack | Free slack |
| --- | --- | --- | --- | --- | --- | --- | --- | --- |
| 399 | 2.1.14.2 | **Utility Construction Plans (Utility TO 2)** | 50d | 2019-02-28 | 2019-05-08 |  | 32d |  |
| 400 | 2.1.14.2.1 | Prepare and submit 30% UC plans to NCDOT & utility owners | 5d | 2019-02-28 | 2019-03-06 | 270, 411 | 32d | 0d |
| 401 | 2.1.14.2.2 | NCDOT & utility owner review of 30% plans | 5d | 2019-03-07 | 2019-03-13 | 400 | 32d | 0d |
| 402 | 2.1.14.2.3 | Incorporate 30% plan review comments and submit 60% UC plans and prelin. Quantities to NCDOT & Utility Owners | 5d | 2019-03-14 | 2019-03-20 | 401 | 32d | 0d |
| 403 | 2.1.14.2.4 | NCDOT & utility owner review of 60% plans | 5d | 2019-03-21 | 2019-03-27 | 402 | 32d | 0d |
| 404 | 2.1.14.2.5 | Incorporate 60% plan review comments and submit 90% UC plans including quantities and SPs to NCDOT & utility owners | 5d | 2019-03-28 | 2019-04-03 | 403 | 32d | 0d |
| 405 | 2.1.14.2.6 | NCDOT & utility owner review of 90% plans, quantities, ans SPs | 5d | 2019-04-04 | 2019-04-10 | 404 | 32d | 0d |
| 406 | 2.1.14.2.7 | Incorporate 90% review comments and submit 100% DocuSinged UC plan package to NCDOT & utility owners | 5d | 2019-04-11 | 2019-04-17 | 405 | 32d | 0d |
| 407 | 2.1.14.2.8 | NCDOT & utility owners approve UC plan package | 5d | 2019-04-18 | 2019-04-24 | 406 | 32d | 0d |
| 408 | 2.1.14.2.9 | Submit UC plan package to NCDEQ- PWSS | 5d | 2019-04-25 | 2019-05-01 | 407 | 32d | 0d |
| 409 | 2.1.14.2.10 | NCDEQ PWSS review and issuance of Authorization to Construct (ATC) | 5d | 2019-05-02 | 2019-05-08 | 408 | 32d | 23d |
| 410 | 2.1.15 | **Signal Design Plans** | 173d | 2018-10-25 | 2019-06-24 |  | 72d |  |
| 411 | 2.1.15.1 | **90% Signal Designs- Final and Temporary Signal Designs** | 15d | 2018-10-25 | 2018-11-14 |  | 107d | 75d |
| 412 | 2.1.15.1.1 | Prepare Pole Locations for Utility Coordination | 5d | 2018-10-25 | 2018-10-31 | 256 | 107d | 0d |
| 413 | 2.1.15.1.2 | Prepare and submit 90% Signal Designs & Plans | 5d | 2018-11-01 | 2018-11-07 | 412 | 107d | 0d |
| 414 | 2.1.15.1.3 | NCDOT review of 90% Signal Designs & Plans | 5d | 2018-11-08 | 2018-11-14 | 413 | 107d |  |
| 415 | 2.1.15.2 | **100% Signal Designs- Final and Temporary Signal Designs** | 36d | 2019-05-06 | 2019-06-24 |  | 12d |  |
| 416 | 2.1.15.2.1 | Incorporate 90% plan review comments and submit 100% Final Signal Plans & SPs to NCDOT | 5d | 2019-05-06 | 2019-05-10 | 414, 296SS | 12d | 0d |
| 417 | 2.1.15.2.2 | NCDOT review of 100% Final Signal Plans & SPs | 5d | 2019-05-13 | 2019-05-17 | 416, 274 | 12d | 0d |
| 418 | 2.1.15.2.3 | Revise and resubmit 100% Final Signal Plans & SPs | 5d | 2019-05-20 | 2019-05-24 | 417 | 12d | 0d |
| 419 | 2.1.15.2.4 | NCDOT review of revised 100% Final Signal Plans & SPs | 5d | 2019-05-27 | 2019-05-31 | 418 | 12d | 0d |
| 420 | 2.1.15.2.5 | Submit 100% Final Signal Plans & SPs to NCDOT (Plan Checking) | 5d | 2019-06-03 | 2019-06-07 | 419 | 12d | 0d |
| 421 | 2.1.15.2.6 | NCDOT (Plan Checking) review of 100% Final Signal Plans & SPs | 5d | 2019-06-10 | 2019-06-14 | 420 | 12d | 0d |
| 422 | 2.1.15.2.7 | NCDOT (Plans Checking) approves 100% Signal Plans & SPs | 5d | 2019-06-17 | 2019-06-21 | 421 | 72d | 0d |
| 423 | 2.1.15.2.8 | Final Signal Plans Approved | 1d | 2019-06-24 | 2019-06-24 | 422 | 72d |  |

| ID | WBS | Task | Type | Duration | Start | Finish | Predecessors | Total slack | Free slack | Constraint |
| --- | --- | --- | --- | --- | --- | --- | --- | --- | --- | --- |
| 424 | 2.1.16 | **Signal Communication-ITS cable routing** |  | 68d | 2019-05-06 | 2019-08-07 |  | 11d |  |  |
| 425 | 2.1.16.1 | **90% Cable Routing Plans** |  | 15d | 2019-07-18 | 2019-08-07 |  | 40d |  |  |
| 426 | 2.1.16.1.1 | Field Surveys |  | 5d | 2019-07-18 | 2019-07-24 | 287SS | 40d | 0d | start no earlier than 2019-07-18 |
| 427 | 2.1.16.1.2 | Prepare and Submit 90% Cable Routing Plans |  | 5d | 2019-07-25 | 2019-07-31 | 426 | 40d | 0d |  |
| 428 | 2.1.16.1.3 | NCDOT Review of 90% Cable Routing Plans |  | 5d | 2019-08-01 | 2019-08-07 | 427 | 40d |  |  |
| 429 | 2.1.16.2 | **100% Cable Routing Plans** |  | 31d | 2019-05-06 | 2019-06-17 |  | 11d |  |  |
| 430 | 2.1.16.2.1 | Incorporate 90% Plan Review Comments and Submit 100% Cable Routing Plans to NCDOT (Division) |  | 5d | 2019-05-06 | 2019-05-10 | 296SS | 11d | 0d |  |
| 431 | 2.1.16.2.2 | NCDOT Review of 100% Cable Routing Plans |  | 5d | 2019-05-13 | 2019-05-17 | 430 | 11d | 0d |  |
| 432 | 2.1.16.2.3 | Revise and Resubmit 100% Cable Routing Plans |  | 5d | 2019-05-20 | 2019-05-24 | 431 | 11d | 0d |  |
| 433 | 2.1.16.2.4 | NCDOT Review of Revised 100% Cable Routing Plans |  | 5d | 2019-05-27 | 2019-05-31 | 432 | 11d | 0d |  |
| 434 | 2.1.16.2.5 | Submit 100% Cable Routing Plans to NCDOT (Plan Checking) |  | 5d | 2019-06-03 | 2019-06-07 | 433 | 11d | 0d |  |
| 435 | 2.1.16.2.6 | NCDOT (Plan Checking) Review of 100% Cable Routing Plans |  | 5d | 2019-06-10 | 2019-06-14 | 434 | 11d | 0d |  |
| 436 | 2.1.16.2.7 | NCDOT Approves 100% Cable Routing Plans |  | 1d | 2019-06-17 | 2019-06-17 | 435 | 11d | 2d |  |
| 437 | 2.1.17 | Prepare Sealed DocuSign Plan set |  | 5d | 2019-06-20 | 2019-06-26 | 302, 315, 354, 421, 436 | 9d | 0d |  |
| 438 | 2.1.18 | PS&E Package submitted to DOT PM for review |  | 10d | 2019-06-27 | 2019-07-10 | 437 | 9d | 0d |  |
| 439 | 2.1.19 | PS&E package turned into Contract Standards & Development |  | 50d | 2019-07-11 | 2019-09-18 | 438 | 9d | 0d |  |
| 440 | 2.1.20 | Advertise Project |  | 1d | 2019-09-19 | 2019-09-19 | 439 | 9d |  |  |
| 441 | 2.1.21 | Let Project | milestone | 0d | 2019-10-02 | 2019-10-02 | 440 | 0d |  | start no earlier than 2019-10-02 |
